# Издание номера журнала

Schedule from MS Project, 2002-01-10 to 2002-04-09, status date 2002-02-10, costs in $.
MS Project 2002
Соотношение затрат на ресурсы разных типов. Заполянем код структуры для ресурсов.

## Calendars

- Standard: Mon-Thu 09:00-12:00, 13:00-18:00; Fri 08:00-12:00, 13:00-17:00; Sat-Sun off. Exceptions (off unless hours are given): 2002-02-25, 2002-03-08.

## Resources

| Resource | Group | Rate | Cost per use |
| --- | --- | --- | --- |
| Иванов | Редактор раздела | 6.25 |  |
| Бумага для типографии |  | 15 |  |
| Фотомодель по контракту | Фотомодель |  | 200 |
| Терехов | Оператор печатного аппарата | 2.5 |  |
| Тарарухин | Оператор печатного аппарата | 3.44 |  |
| Борисов | Оператор печатного аппарата | 3.12 |  |
| Семенов | Оператор Mac | 4.69 |  |
| Бурков | Оператор Mac | 3.12 |  |
| Лимонов | Оператор Mac | 5 |  |
| Улендеева | Верстальщик | 4.69 |  |
| Сергеева | Верстальщик | 3.75 |  |
| Жуков | Фотограф | 3.12 |  |
| Еремин | Дизайнер | 7.5 |  |
| Ураганов | Корректор | 500 |  |
| Баранов | Корректор | 500 |  |
| Козлов | Технический редактор | 800 |  |
| Васин | Технический редактор | 800 |  |
| Уваров | Главный редактор | 2000 |  |
| Галкина | Отвественный секретарь | 3.12 |  |
| Сидоров | Редактор раздела | 6.25 |  |
| Петров | Редактор раздела | 6.25 |  |
| Краска для вывода пленок |  | 100 |  |
| Фотопленка |  | 2 |  |
| Тарасова | Верстальщик | 3.75 |  |
| Авторы |  | 0.25 |  |

## Schedule

| ID | WBS | Task | Type | Duration | Start | Finish | Predecessors | Total slack | Free slack | Constraint | Resources | Work | Cost |
| --- | --- | --- | --- | --- | --- | --- | --- | --- | --- | --- | --- | --- | --- |
| 1 | МАЙ//001 | **Планирование номера** |  | 11.6d | 2002-01-10 | 2002-01-25 |  | -0.1d | 0d |  |  | 88.62h | 18,475.77 |
| 2 | МАЙ//001.A | Сбор предложений от авторов |  | 5d | 2002-01-10 | 2002-01-16 |  | -0.1d | 0d |  | Иванов [25%]; Петров [25%]; Сидоров [25%] | 15h | 93.75 |
| 3 | МАЙ//001.B | Подготовка плана номера |  | 3d | 2002-01-17 | 2002-01-21 | 2 | -0.1d | 0d |  | Иванов [25%]; Петров [25%]; Сидоров [25%]; Уваров [12.5%] | 20h | 4,112.5 |
| 4 | МАЙ//001.C | Предварительная редколлегия |  | 3.17h | 2002-01-22 | 2002-01-22 | 3 | -0.1d | 0d |  | Иванов; Петров; Сидоров; Галкина; Уваров | 15.83h | 6,402.6 |
| 5 | МАЙ//001.D | Доработка планов с учетом замечаний |  | 2.73d | 2002-01-22 | 2002-01-25 | 4 | -0.1d | 0d |  | Иванов; Петров; Сидоров | 18.62h | 116.4 |
| 6 | МАЙ//001.E | Редколлегия |  | 3.83h | 2002-01-25 | 2002-01-25 | 5 | -0.1d | 0d | start no later than 2002-01-25 | Иванов; Петров; Сидоров; Галкина; Уваров | 19.17h | 7,750.52 |
| 7 | МАЙ//001.F | План номера утвержден | milestone | 0d | 2002-01-25 | 2002-01-25 | 6FS-1h | -0.1d | 0d |  |  |  |  |
| 8 | МАЙ//002 | **Подготовка материалов** |  | 36.09d | 2002-01-25 | 2002-03-20 | 7 | 0d |  |  |  | 336.29h | 40,312.34 |
| 9 | МАЙ//002.A | **Подготовка обложки** |  | 31.34d | 2002-02-01 | 2002-03-20 |  | 0d |  |  |  | 99.96h | 585.25 |
| 10 | МАЙ//002.A-a | Отбор модели |  | 13.83h | 2002-02-01 | 2002-02-04 |  | 0d |  | must start on 2002-02-01 | Еремин [50%] | 6.92h | 51.87 |
| 11 | МАЙ//002.A-b | Фотосъемка модели |  | 3.42d | 2002-02-04 | 2002-02-08 | 10 | 23.56d | 23.19d |  | Жуков; Фотомодель по контракту; Фотопленка | 54.64h | 287.38 |
| 12 | МАЙ//002.A-c | Подготовка анонсов материалов номера для обложки |  | 3d | 2002-03-12 | 2002-03-15 | 22FS-5% | 0.37d | 0d |  | Сидоров [70%] | 16.8h | 105 |
| 13 | МАЙ//002.A-d | Передача рекламных анонсов в предыдущий номер | milestone | 1d | 2002-02-26 | 2002-02-27 | 22FS-5% | 27.53d |  |  |  |  |  |
| 14 | МАЙ//002.A-e | Верстка обложки |  | 3d | 2002-03-15 | 2002-03-20 | 12, 11 | 0.37d | 0d |  | Еремин [70%]; Жуков [20%] | 21.6h | 141 |
| 15 | МАЙ//002.A-f | Обложка готова | milestone | 0d | 2002-03-20 | 2002-03-20 | 14 | 0.37d | 0d |  |  |  |  |
| 16 | МАЙ//002.B | **Подготовка текстов** |  | 26.34d | 2002-01-25 | 2002-03-05 |  | 0d |  |  |  | 236.34h | 39,727.09 |
| 17 | МАЙ//002.B-a | Подготовка редакционных заданий |  | 2.75d | 2002-01-25 | 2002-01-30 |  | -0.1d | 0d | start no later than 2002-01-25 | Иванов; Петров; Сидоров; Галкина | 67.95h | 370.96 |
| 18 | МАЙ//002.B-b | Рассылка заданий авторам |  | 1.34d | 2002-01-30 | 2002-01-31 | 17 | 0.29d | 0d |  | Галкина [33.3%] | 1.96h | 6.12 |
| 19 | МАЙ//002.B-c | Утверждение заданий авторами |  | 2d | 2002-01-31 | 2002-02-04 | 18 | 0.29d | 0d |  | Галкина [12.5%] | 2h | 6.25 |
| 20 | МАЙ//002.B-d | Статьи в работе у авторов | milestone | 0d | 2002-02-04 | 2002-02-04 | 19 | 0.29d | 0d |  |  |  |  |
| 21 | МАЙ//002.B-e | Статьи поступили в редакцию | milestone | 0d | 2002-02-18 | 2002-02-18 | 20FS+10d | 0.29d | 0d |  | Авторы |  | 1,000 |
| 22 | 002.B-f | **Редактирование материалов** |  | 10d | 2002-02-18 | 2002-03-05 | 21 | 0.29d | 0d |  |  | 84h | 525 |
| 23 | 2.2.6.1 | Редактирование раздела 1 |  | 10d | 2002-02-18 | 2002-03-05 |  | 0.29d |  |  | Иванов [70%] | 28h | 175 |
| 24 | 2.2.6.2 | Редактирование раздела 2 |  | 10d | 2002-02-18 | 2002-03-05 |  | 0.29d |  |  | Петров [70%] | 28h | 175 |
| 25 | 2.2.6.3 | Редактирование раздела 3 |  | 10d | 2002-02-18 | 2002-03-05 |  | 0.29d |  |  | Сидоров [70%] | 28h | 175 |
| 26 | МАЙ//002.B-g | Техническое редактирование |  | 4.17d | 2002-02-20 | 2002-02-27 | 22SS+2d | 3.12d | 0d |  | Иванов [30%]; Петров [30%]; Сидоров [30%]; Галкина [50%]; Васин; Козлов | 80.42h | 37,818.76 |
| 27 | МАЙ//002.B-h | Тексты готовы | milestone | 0d | 2002-02-27 | 2002-02-27 | 26 | 27.37d |  |  |  |  |  |
| 28 | МАЙ//002.C | Подготовка материалов завершена | milestone | 0d | 2002-02-27 | 2002-02-27 | 26 | 27.37d |  |  |  |  |  |

Notes:
- 2: Text1: Файл предложений в редакционном формате.
- 3: Text1: План номера в формате XLS с названиями статей от редакторов разделов.
- 4: Text1: Предварительный план номиера обсужден.
- 5: Text1: Планы каждого из редакторов разделов доработаны с учетом замечаний.
- 6: Задания на этот номер должны включать темы: / ·летний отдых; / ·фотокамеры; / ·видеокамеры. / Text1: Окончательный план номера согласован с редакторами разделов и главным редактором.
- 13: Шаблон документа для передачи анонсов.
- 17: Подготовить задания нужно за 3 дня!
- 19: Авторы должны уложиться в 2 дня!
- 22: Сокращено до 12 дней.

| ID | WBS | Task | Type | Duration | Start | Finish | Predecessors | Total slack | Free slack | Constraint | Resources | Work | Cost |
| --- | --- | --- | --- | --- | --- | --- | --- | --- | --- | --- | --- | --- | --- |
| 29 | МАЙ//003 | **Верстка журнала** |  | 26.64d | 2002-02-26 | 2002-04-05 |  | 1.89d |  |  |  | 502.13h | 125,638.06 |
| 30 | МАЙ//003.A | Обработка текста и иллюстраций |  | 10.17d | 2002-02-26 | 2002-03-13 | 26SS+3d | 3.12d | 0d |  | Тарасова [98.4%]; Улендеева [98.4%] | 160h | 675 |
| 31 | МАЙ//003.B | Вычитка |  | 20.17d | 2002-03-01 | 2002-04-01 | 30SS+3d | 5.37d |  |  | Баранов [50%]; Ураганов [50%] | 161.33h | 80,666.66 |
| 32 | МАЙ//003.C | Сверка |  | 14.35d | 2002-03-18 | 2002-04-05 | 31SS+3d | 1.89d |  | start no earlier than 2002-03-18 | Иванов [30%]; Петров [30%]; Сидоров [50%]; Баранов [50%]; Ураганов [50%] | 170.75h | 42,646.09 |
| 33 | МАЙ//003.D | Подготовка оглавления |  | 1.83d | 2002-03-13 | 2002-03-15 | 30 | 3.12d | 2.75d |  | Сидоров [30%] | 3.72h | 23.23 |
| 34 | МАЙ//003.E | Окончательная сборка |  | 2.17d | 2002-03-20 | 2002-03-22 | 33, 15 | 0.37d | 0d |  | Сидоров [62.5%]; Васин [25%] | 6.33h | 1,627.08 |
| 35 | МАЙ//003.F | Номер сверстан | milestone | 0d | 2002-03-22 | 2002-03-22 | 34 | 0.37d | 0d |  |  |  |  |
| 36 | МАЙ//004 | **Предпечатная подготовка** |  | 11.62d | 2002-03-22 | 2002-04-09 | 35 | 0d |  |  |  | 249.47h | 1,022.14 |
| 37 | МАЙ//004.A | Конвертция сверстанного номера в формат Mac |  | 3d | 2002-03-22 | 2002-03-24 |  | 0d |  |  | Лимонов [76.9%]; Бурков [98.8%]; Семенов [76.9%] | 45.61h | 180.12 |
| 38 | МАЙ//004.B | Цветоделение |  | 6.28d | 2002-03-24 | 2002-03-29 | 37 | 0d |  |  | Бурков [20%]; Семенов [20%]; Борисов [25%]; Тарарухин [20%]; Терехов [20%]; Бумага для типографии | 33.73h | 128.41 |
| 39 | МАЙ//004.C | Коррекция |  | 6.92d | 2002-03-25 | 2002-03-29 | 38SS+1d | 0d |  |  | Лимонов [25%]; Бурков [25%]; Семенов [25%] | 41.5h | 177.23 |
| 40 | МАЙ//004.D | Вывод пленок |  | 13.74d | 2002-03-27 | 2002-04-09 | 39SS+2d | 0d |  |  | Лимонов [34.8%]; Бурков [34.8%]; Борисов [41.8%]; Тарарухин [41.8%]; Терехов [41.8%]; Краска для вывода пленок | 128.63h | 536.38 |
| 41 | МАЙ//004.E | Номер готов к передаче в типографию | milestone | 0d | 2002-04-09 | 2002-04-09 | 40 | 0d |  |  |  |  |  |
